# DEFENSAS RIBEREÑAS DEL RIO LACRAMARCA - PAQUETE R-07 - QDA. PAMPA DEL TORO

Schedule from Primavera P6, 2022-11-07 to 2022-12-21, data date 2022-11-07, costs in PEN.

## Calendars

- PAQUETE R-07: Mon-Sun 08:00-16:00.

## Resources

| Resource | Group | Rate |
| --- | --- | --- |
| Canal Revestido Tramo 6 | labor | 1 |

## Schedule

| ID | WBS | Activity | Type | Duration | Start | Finish | Predecessors | Total float | Free float | Resources | Cost |
| --- | --- | --- | --- | --- | --- | --- | --- | --- | --- | --- | --- |
| A1640 |  | INICIO DE PROYECTO | milestone | 0d | 2022-11-07 | 2022-11-07 |  | 0d |  |  |  |
| A1710 |  | FIN DE PROYECTO | milestone | 0d | 2022-12-21 | 2022-12-21 | A1011, A1740, A1881, A1921, A1961, A1991, A2001, A2011, A2021, A1009, A1180, A1213, A1620, A1770, A1791, A1811, A1851, A1971 | 0d |  |  |  |
|  | 1 | **OBRAS PRELIMINARES** |  |  | 2022-11-07 | 2022-12-21 |  |  |  |  |  |
| A1000 |  | PROCESO DE INGRESO DE PERSONAL |  | 15d | 2022-11-07 | 2022-11-21 | A1640 | 0d |  |  |  |
| A1010 |  | INSTALACIONES PROVISIONALES PARA LA OBRA |  | 14d | 2022-11-22 | 2022-12-05 | A1000 | 0d |  | Canal Revestido Tramo 6 [50000 h] | 50,000 |
| A1011 |  | MANTENIMIENTO DE TRANSITO Y SEGURIDAD VIAL |  | 30d | 2022-11-22 | 2022-12-21 | A1000 | 0d |  | Canal Revestido Tramo 6 [102500 h] | 102,500 |
| A1009 |  | CARTEL DE IDENTIFICACIÓN DE OBRA 4.8 m x 3.60 m |  | 7d | 2022-11-29 | 2022-12-05 | A1010 SS+7d | 16d |  | Canal Revestido Tramo 6 [2800 h] | 2,800 |
|  | 4 | **TRABAJOS PRELIMINARES** |  |  | 2022-11-22 | 2022-12-21 |  |  |  |  |  |
| A1760 |  | MOVILIZACION DE EQUIPOS |  | 10d | 2022-11-22 | 2022-12-01 | A1010 SS | 0d |  | Canal Revestido Tramo 6 [36000 h] | 36,000 |
| A1771 |  | TOPOGRAFIA Y GEOREFERENCIACION |  | 7d | 2022-11-22 | 2022-11-28 | A1760 SS | 0d |  | Canal Revestido Tramo 6 [43000 h] | 43,000 |
| A1770 |  | DESMOVILIZACION DE EQUIPOS |  | 7d | 2022-12-15 | 2022-12-21 | A1740 FF, A1881 FF | 0d |  | Canal Revestido Tramo 6 [36000 h] | 36,000 |
|  | 3 | **MEJORAMIENTO DE VÍAS EXISTENTES** |  |  | 2022-11-22 | 2022-12-02 |  |  |  |  |  |
|  | 5 | **MOVIMIENTO DE TIERRAS** |  |  | 2022-11-22 | 2022-12-01 |  |  |  |  |  |
| A1781 |  | ROCE Y LIMPIEZA DE MALEZA |  | 4d | 2022-11-22 | 2022-11-25 | A1771 SS | 19d | 0d | Canal Revestido Tramo 6 [18726.6 h] | 18,726.59 |
| A1791 |  | MEJORAMIENTO DE VIAS EXISTENTES |  | 10d | 2022-11-22 | 2022-12-01 | A1781 SS | 20d |  | Canal Revestido Tramo 6 [222808 h] | 222,807.59 |
|  | 1 | **REPOSICIÓN DE ESTRUCTURAS** |  |  | 2022-11-26 | 2022-12-02 |  |  |  |  |  |
| A1160 |  | DEMOLICIÓN DE ESTRUCTURAS EXISTENTES |  | 3d | 2022-11-26 | 2022-11-28 | A1781 | 19d | 0d | Canal Revestido Tramo 6 [327.03 h] | 327.03 |
| A1190 |  | SUMINISTRO Y MONTAJE DE LOSAS DE C°A° 1.6mx1.0mx0.20m EN PASE DE AGUA |  | 3d | 2022-11-26 | 2022-11-28 | A1160 SS | 19d | 0d | Canal Revestido Tramo 6 [366.37 h] | 366.37 |
| A1170 |  | REPOSICIÓN DE PASE DE AGUA TUBERÍA HDPE Ø=36" |  | 6d | 2022-11-27 | 2022-12-02 | A1160 SS+1d | 19d | 0d | Canal Revestido Tramo 6 [14389.6 h] | 14,389.65 |
| A1180 |  | REPOSICIÓN DE PASE DE AGUA TUBERÍA HDPE Ø=24" |  | 6d | 2022-11-27 | 2022-12-02 | A1170 SS | 19d |  | Canal Revestido Tramo 6 [11756.9 h] | 11,756.94 |
|  | 2 | **ESTRUCTURAS DE CONCRETO** |  |  | 2022-11-29 | 2022-12-02 |  |  |  |  |  |
| A1801 |  | CONCRETO 175 Kg/Cm2 |  | 4d | 2022-11-29 | 2022-12-02 | A1160, A1190 | 19d | 0d | Canal Revestido Tramo 6 [1915.95 h] | 1,915.95 |
| A1811 |  | ENCOFRADO Y DESENCOFRADO NORMAL |  | 1d | 2022-11-29 | 2022-11-29 | A1801 SS | 22d |  | Canal Revestido Tramo 6 [2530.11 h] | 2,530.11 |
|  | 2 | **DIQUES Y PROTECCIÓN DE CAUCE CON ENROCADO** |  |  | 2022-11-22 | 2022-12-21 |  |  |  |  |  |
|  | 1 | **DIQUE DE TIERRA COMPACTADA A4-PT-D-05** |  |  | 2022-11-22 | 2022-12-21 |  |  |  |  |  |
| A1200 |  | DESBROCE Y LIMPIEZA EN ZONA NO BOSCOSA |  | 4d | 2022-11-22 | 2022-11-25 | A1771 SS | 0d |  | Canal Revestido Tramo 6 [9878.62 h] | 9,878.62 |
| A1210 |  | EXCAVACIÓN EN TERRENO NATURAL CON EQUIPO |  | 14d | 2022-12-02 | 2022-12-15 | A1200, A1240 | 0d |  | Canal Revestido Tramo 6 [4163.82 h] | 4,163.82 |
| A1211 |  | PERFILADO Y COMPACTACIÓN EN ZONA DE CORTE |  | 8d | 2022-12-05 | 2022-12-12 | A1210 SS+3d | 0d |  | Canal Revestido Tramo 6 [5551.06 h] | 5,551.06 |
| A1212 |  | CONFORMACIÓN DE CUERPO DE DIQUE |  | 10d | 2022-12-05 | 2022-12-14 | A1211 SS | 0d |  | Canal Revestido Tramo 6 [26978.2 h] | 26,978.25 |
| A1220 |  | GEOTEXTIL NO TEJIDO 400 G/M2, INC. COLOCACIÓN |  | 7d | 2022-12-05 | 2022-12-11 | A1212 SS | 0d |  | Canal Revestido Tramo 6 [9390.71 h] | 9,390.71 |
| A1730 |  | COLOCACION Y ACOMODO DE ROCA EN UÑA DE DIQUE |  | 7d | 2022-12-08 | 2022-12-14 | A1220 SS+3d | 0d |  | Canal Revestido Tramo 6 [44629.2 h] | 44,629.2 |
| A1213 |  | CONFORMACIÓN DE MATERIAL GRANULAR EN CORONA DE DIQUE |  | 9d | 2022-12-09 | 2022-12-17 | A1212 SS+4d | 4d |  | Canal Revestido Tramo 6 [6903.45 h] | 6,903.45 |
| A1740 |  | COLOCACION Y ACOMODO DE ROCA EN TALUD DE DIQUE |  | 11d | 2022-12-11 | 2022-12-21 | A1730 SS+3d | 0d |  | Canal Revestido Tramo 6 [16697.9 h] | 16,697.93 |

| ID | WBS | Activity | Duration | Start | Finish | Predecessors | Total float | Free float | Resources | Cost |
| --- | --- | --- | --- | --- | --- | --- | --- | --- | --- | --- |
|  | 2 | **DIQUE DE TIERRA COMPACTADA A4-PT-D-04** |  | 2022-12-02 | 2022-12-21 |  |  |  |  |  |
| A1230 |  | DESBROCE Y LIMPIEZA EN ZONA NO BOSCOSA | 4d | 2022-12-02 | 2022-12-05 | A1240 | 0d |  | Canal Revestido Tramo 6 [2597.77 h] | 2,597.77 |
| A1821 |  | EXCAVACIÓN EN TERRENO NATURAL CON EQUIPO | 7d | 2022-12-02 | 2022-12-08 | A1230 SS | 0d |  | Canal Revestido Tramo 6 [1293.21 h] | 1,293.21 |
| A1831 |  | PERFILADO Y COMPACTACIÓN EN ZONA DE CORTE | 7d | 2022-12-05 | 2022-12-11 | A1821 SS+3d | 0d |  | Canal Revestido Tramo 6 [1507.94 h] | 1,507.94 |
| A1841 |  | CONFORMACIÓN DE CUERPO DE DIQUE | 7d | 2022-12-08 | 2022-12-14 | A1831 SS+3d | 0d |  | Canal Revestido Tramo 6 [6769.72 h] | 6,769.72 |
| A1861 |  | GEOTEXTIL NO TEJIDO 400 G/M2, INC. COLOCACIÓN | 7d | 2022-12-08 | 2022-12-14 | A1841 SS | 0d |  | Canal Revestido Tramo 6 [2666.59 h] | 2,666.59 |
| A1871 |  | COLOCACION Y ACOMODO DE ROCA EN UÑA DE DIQUE | 5d | 2022-12-10 | 2022-12-14 | A1861 SS+2d | 0d |  | Canal Revestido Tramo 6 [11031.4 h] | 11,031.35 |
| A1851 |  | CONFORMACIÓN DE MATERIAL GRANULAR EN CORONA DE DIQUE | 9d | 2022-12-11 | 2022-12-19 | A1841 SS+3d | 2d |  | Canal Revestido Tramo 6 [1706.29 h] | 1,706.29 |
| A1881 |  | COLOCACION Y ACOMODO DE ROCA EN TALUD DE DIQUE | 10d | 2022-12-12 | 2022-12-21 | A1871 SS+2d | 0d |  | Canal Revestido Tramo 6 [7843.63 h] | 7,843.63 |
|  | 3 | **PROTECCIÓN DE TALUDES** |  | 2022-11-26 | 2022-12-18 |  |  |  |  |  |
| A1240 |  | DESBROCE Y LIMPIEZA EN ZONA NO BOSCOSA | 6d | 2022-11-26 | 2022-12-01 | A1200 | 0d |  | Canal Revestido Tramo 6 [5510.11 h] | 5,510.11 |
| A1250 |  | EXCAVACIÓN EN TERRENO NATURAL CON EQUIPO | 4d | 2022-12-02 | 2022-12-05 | A1240 | 3d | 0d | Canal Revestido Tramo 6 [4094.19 h] | 4,094.19 |
| A1260 |  | PERFILADO Y COMPACTACIÓN EN ZONA DE CORTE | 5d | 2022-12-04 | 2022-12-08 | A1250 SS+2d | 3d | 0d | Canal Revestido Tramo 6 [2546.95 h] | 2,546.95 |
| A1891 |  | RELLENO ESTRUCTURAL CON MATERIAL PROPIO | 7d | 2022-12-04 | 2022-12-10 | A1260 SS | 3d | 0d | Canal Revestido Tramo 6 [4681.46 h] | 4,681.46 |
| A1901 |  | GEOTEXTIL NO TEJIDO 400 G/M2, INC. COLOCACIÓN | 9d | 2022-12-06 | 2022-12-14 | A1891 SS+2d | 3d | 0d | Canal Revestido Tramo 6 [9597.37 h] | 9,597.37 |
| A1911 |  | COLOCACION Y ACOMODO DE ROCA EN UÑA DE DIQUE | 7d | 2022-12-08 | 2022-12-14 | A1901 SS+2d | 3d | 0d | Canal Revestido Tramo 6 [35569.7 h] | 35,569.74 |
| A1921 |  | COLOCACION Y ACOMODO DE ROCA EN TALUD DE DIQUE | 7d | 2022-12-12 | 2022-12-18 | A1911 SS+4d | 3d |  | Canal Revestido Tramo 6 [33844.6 h] | 33,844.63 |
|  | 6 | **REPOSICIÓN DE CAMINO DE ACCESO A4-RC-1** |  | 2022-11-22 | 2022-12-03 |  |  |  |  |  |
| A1500 |  | DESBROCE Y LIMPIEZA EN ZONA NO BOSCOSA | 4d | 2022-11-22 | 2022-11-25 | A1771 SS | 11d | 0d | Canal Revestido Tramo 6 [5316.29 h] | 5,316.29 |
| A1510 |  | EXCAVACIÓN EN MATERIAL SUELTO CON EQUIPO | 4d | 2022-11-25 | 2022-11-28 | A1500 SS+3d | 11d | 0d | Canal Revestido Tramo 6 [3297.45 h] | 3,297.45 |
| A1520 |  | PERFILADO Y COMPACTACIÓN EN ZONA DE CORTE | 4d | 2022-11-26 | 2022-11-29 | A1510 SS+1d | 11d | 0d | Canal Revestido Tramo 6 [3411.73 h] | 3,411.73 |
| A1530 |  | MATERIAL AFIRMADO e=25 cm | 6d | 2022-11-28 | 2022-12-03 | A1520 SS+2d | 11d | 0d | Canal Revestido Tramo 6 [14927.7 h] | 14,927.69 |
|  | 7 | **PROTECCIÓN DEL CAUCE CON ENROCADO** |  | 2022-12-01 | 2022-12-10 |  |  |  |  |  |
| A1931 |  | DESBROCE Y LIMPIEZA EN ZONA NO BOSCOSA | 6d | 2022-12-01 | 2022-12-06 | A1530 SS+3d | 11d | 0d | Canal Revestido Tramo 6 [2711.2 h] | 2,711.2 |
| A1941 |  | EXCAVACIÓN EN MATERIAL SUELTO CON EQUIPO | 7d | 2022-12-01 | 2022-12-07 | A1931 SS | 11d | 0d | Canal Revestido Tramo 6 [3826.45 h] | 3,826.45 |
| A1951 |  | PERFILADO Y COMPACTACIÓN CON EQUIPO DE FONDO DE EXCAVACIÓN | 4d | 2022-12-04 | 2022-12-07 | A1941 SS+3d | 11d | 0d | Canal Revestido Tramo 6 [1536.27 h] | 1,536.27 |
| A1961 |  | COLOCACION DE ROCA EN CAUCE | 4d | 2022-12-07 | 2022-12-10 | A1951 SS+3d | 11d |  | Canal Revestido Tramo 6 [49877.4 h] | 49,877.43 |

| ID | WBS | Activity | Duration | Start | Finish | Predecessors | Total float | Free float | Resources | Cost |
| --- | --- | --- | --- | --- | --- | --- | --- | --- | --- | --- |
|  | 9 | **TRANSPORTE DE MATERIAL** |  | 2022-11-22 | 2022-12-11 |  |  |  |  |  |
| A1630 |  | TRANPORTE DE ROCA PARA DISTANCIAS <1KM | 14d | 2022-11-22 | 2022-12-05 | A1000 | 16d | 0d | Canal Revestido Tramo 6 [18893.4 h] | 18,893.4 |
| A1971 |  | TRANPORTE DE ROCA PARA DISTANCIAS >1KM | 14d | 2022-11-22 | 2022-12-05 | A1630 SS | 16d |  | Canal Revestido Tramo 6 [128007 h] | 128,006.88 |
| A1981 |  | TRANPORTE DE MATERIAL EXCEDENTE PARA DISTANCIAS <1KM | 10d | 2022-12-02 | 2022-12-11 | A1210 SS | 5d | 0d | Canal Revestido Tramo 6 [1426.83 h] | 1,426.83 |
| A1991 |  | TRANPORTE DE MATERIAL EXCEDENTE PARA DISTANCIAS >1KM | 10d | 2022-12-02 | 2022-12-11 | A1981 SS | 10d |  | Canal Revestido Tramo 6 [3031.14 h] | 3,031.14 |
| A1610 |  | TRANPORTE DE MATERIAL GRANULAR PARA DISTANCIAS <1KM | 4d | 2022-12-05 | 2022-12-08 | A1212 SS | 13d | 0d | Canal Revestido Tramo 6 [2991.94 h] | 2,991.94 |
| A1620 |  | TRANPORTE DE MATERIAL GRANULAR PARA DISTANCIAS >1KM | 4d | 2022-12-05 | 2022-12-08 | A1610 SS | 13d |  | Canal Revestido Tramo 6 [6930.87 h] | 6,930.87 |
|  | 8 | **PROGRAMA DE CIERRE DE OBRA** |  | 2022-12-09 | 2022-12-16 |  |  |  |  |  |
| A1600 |  | ACONDICIONAMIENTO DE DEPOSITOS DE MATERIALES EXCEDENTES (DME) | 2d | 2022-12-09 | 2022-12-10 | A1981 SS+7d | 5d | 0d | Canal Revestido Tramo 6 [1242.97 h] | 1,242.97 |
| A2001 |  | RESTAURACIÓN DE ÁREAS DE INSTALACIONES PROVISIONALES | 2d | 2022-12-15 | 2022-12-16 | A1600 FS+4d | 5d |  | Canal Revestido Tramo 6 [3976.75 h] | 3,976.75 |
|  | 10 | **SEGURIDAD Y SALUD OCUPACIONAL** |  | 2022-11-22 | 2022-12-21 |  |  |  |  |  |
| A2011 |  | SEGURIDAD Y SALUD OCUPACIONAL | 30d | 2022-11-22 | 2022-12-21 | A1000 | 0d |  | Canal Revestido Tramo 6 [20423.6 h] | 20,423.6 |
| A2021 |  | IMPLEMENTACIÓN DEL PLAN PARA LA VIGILANCIA, PREVENCIÓN Y CONTROL DE COVID-19 EN EL TRABAJO | 30d | 2022-11-22 | 2022-12-21 | A1000 | 0d |  | Canal Revestido Tramo 6 [14961 h] | 14,961 |
